# WP3 update

Schedule from MS Project, 2005-10-28 to 2009-03-31, A marks actual dates.
CLRC

## Calendars

- Standard: Mon-Fri 08:00-12:00, 13:00-17:00; Sat-Sun off.

## Schedule

| ID | WBS | Task | Type | Duration | Start | Finish | Predecessors | Complete | Remaining | Total slack | Free slack | Constraint |
| --- | --- | --- | --- | --- | --- | --- | --- | --- | --- | --- | --- | --- |
| 1 | 1 | **CALICE WP3** |  | 893d? | 2005-10-28 A | 2009-03-31 |  | 14% | 772.44d? | 0d |  |  |
| 2 | 1.1 | Initial feasibility study |  | 131d? | 2005-10-28 A | 2006-04-28 A |  | 100% |  |  |  | start no earlier than 2005-10-28 |
| 3 | 1.2 | Preliminary design review | milestone | 0d | 2006-04-28 A | 2006-04-28 A | 2 | 100% |  |  |  | start no earlier than 2006-04-28 |
| 4 | 1.3 | First sensor design |  | 251d? | 2006-05-01 A | 2007-04-16 | 3 | 38% | 156d? | 148d | 0d | finish no earlier than 2007-04-16 |
| 5 | 1.4 | First sensor interim design review | milestone | 0d | 2007-01-04 | 2007-01-04 |  |  |  | 584d |  | start no earlier than 2007-01-04 |
| 6 | 1.5 | First sensor design review | milestone | 0d | 2007-03-28 | 2007-03-28 |  |  |  | 525d |  | start no earlier than 2007-03-28 |
| 7 | 1.6 | First sensor design to foundry | milestone | 0d | 2007-04-17 | 2007-04-17 | 4 |  |  | 148d | 0d | start no earlier than 2007-04-17 |
| 8 | 1.7 | First sensor fabrication |  | 81d? | 2007-04-17 | 2007-08-07 | 7 |  |  | 148d | 0d | finish no earlier than 2007-08-07 |
| 9 | 1.8 | First sensor fabrication complete | milestone | 0d | 2007-08-07 | 2007-08-07 | 8 |  |  | 148d | 0d | finish no earlier than 2007-08-07 |
| 10 | 1.9 | Prepare test stands |  | 171d? | 2006-12-04 | 2007-07-30 |  |  |  | 154d | 4d | finish no earlier than 2007-07-30 |
| 11 | 1.10 | First sensor basic tests |  | 45d? | 2007-08-08 | 2007-10-09 | 10, 9 |  |  | 148d | 0d | start no earlier than 2007-08-06 |
| 12 | 1.11 | First sensor detailed tests |  | 195d? | 2007-09-03 | 2008-05-30 |  |  |  | 217d |  | start no earlier than 2007-09-03 |
| 13 | 1.12 | Second sensor design |  | 105d? | 2007-10-10 | 2008-03-04 | 11 |  |  | 148d | 0d | start no earlier than 2007-10-09 |
| 14 | 1.13 | Second sensor interim design review | milestone | 0d | 2007-11-26 | 2007-11-26 |  |  |  | 352d |  | start no earlier than 2007-11-26 |
| 15 | 1.14 | Second sensor design review | milestone | 0d | 2008-02-11 | 2008-02-11 |  |  |  | 297d |  | start no earlier than 2008-02-11 |
| 16 | 1.15 | Second sensor design to foundry | milestone | 0d | 2008-03-04 | 2008-03-04 | 13 |  |  | 148d | 0d | start no earlier than 2008-02-25 |
| 17 | 1.16 | Second sensor fabrication |  | 87d? | 2008-03-05 | 2008-07-03 | 16 |  |  | 148d | 0d | start no earlier than 2008-03-03 |
| 18 | 1.17 | Second fabrication complete | milestone | 0d | 2008-07-03 | 2008-07-03 | 17 |  |  | 148d | 0d | start no earlier than 2008-06-30 |
| 19 | 1.18 | Upgrade test stands |  | 44d? | 2008-05-01 | 2008-07-01 |  |  |  | 150d | 0d | start no earlier than 2008-05-01 |
| 20 | 1.19 | Second sensor basic tests |  | 45d? | 2008-07-04 | 2008-09-04 | 18, 19 |  |  | 148d |  | start no earlier than 2008-07-01 |
| 21 | 1.20 | Second sensor detailed tests |  | 172d? | 2008-08-04 | 2009-03-31 |  |  |  | 0d |  | start no earlier than 2008-08-04 |
| 22 | 1.21 | Beam test PCB design and fabrication |  | 260d? | 2007-12-03 | 2008-11-28 |  |  |  | 0d |  | start no earlier than 2007-12-03 |
| 23 | 1.22 | Beam test period |  | 87d? | 2008-12-01 | 2009-03-31 | 22 |  |  | 0d |  | start no earlier than 2008-12-01 |
| 24 | 1.23 | Beams tests start | milestone | 0d | 2009-01-05 | 2009-01-05 |  |  |  | 62d |  | start no earlier than 2009-01-05 |
